# Reunion de accionistas universidad

Schedule from MS Project, 2021-05-03 to 2021-06-18.
Informe anual

## Calendars

- RA2: Mon-Fri 08:00-16:00; Sat-Sun off. Exceptions (off unless hours are given): 2021-05-10 to 2021-05-14 (No 4), 2021-05-24 (No 1), 2021-06-01 (No 2).

## Schedule

| ID | WBS | Task | Type | Duration | Start | Finish | Predecessors | Total slack | Free slack |
| --- | --- | --- | --- | --- | --- | --- | --- | --- | --- |
| 1 | 1 | **Planificacion preliminar** |  | 7d | 2021-05-03 | 2021-05-18 |  | 0d |  |
| 2 | 1.1 | Programar fecha de la conferencia |  | 2d | 2021-05-03 | 2021-05-04 |  | 0d |  |
| 3 | 1.2 | Reservar centro de conferencias |  | 3d | 2021-05-05 | 2021-05-07 | 2 | 0d |  |
| 4 | 1.3 | Buscar conferenciante |  | 3d | 2021-05-07 | 2021-05-18 | 3FS-1d | 0d |  |
| 5 | 1.4 | Planificacion preliminar completa | milestone | 0d | 2021-05-18 | 2021-05-18 | 4 | 19d |  |
| 6 | 2 | **Carta de notificacion** |  | 7d | 2021-05-17 | 2021-05-26 |  | 0d |  |
| 7 | 2.1 | Ordenar lista de envio |  | 1d | 2021-05-17 | 2021-05-17 | 4SS+1d | 0d |  |
| 8 | 2.2 | Preparar carta |  | 3d | 2021-05-17 | 2021-05-19 | 7SS | 0d |  |
| 9 | 2.3 | Revisar carta |  | 1d | 2021-05-20 | 2021-05-20 | 8 | 0d |  |
| 10 | 2.4 | Aprobar carta |  | 1d | 2021-05-21 | 2021-05-21 | 9 | 0d |  |
| 11 | 2.5 | Imprimir carta |  | 1d | 2021-05-25 | 2021-05-25 | 10 | 16d | 0d |
| 12 | 2.6 | Enviar carta | milestone | 1d | 2021-05-26 | 2021-05-26 | 11 | 16d |  |
| 13 | 3 | **Detalles de la reunion** |  | 11d | 2021-05-25 | 2021-06-09 |  | 0d |  |
| 14 | 3.1 | Preparar menu con empresa catering |  | 1w | 2021-05-25 | 2021-05-31 | 10 | 0d |  |
| 15 | 3.2 | Preparar sitio de reunion |  | 1d | 2021-05-31 | 2021-05-31 | 14FF | 0d |  |
| 16 | 3.3 | Preparar equipamiento necesario |  | 2d | 2021-06-02 | 2021-06-03 | 15 | 0d |  |
| 17 | 3.4 | Preparar programa |  | 3d | 2021-06-04 | 2021-06-08 | 16 | 0d |  |
| 18 | 3.5 | Imprimir programa |  | 1d | 2021-06-09 | 2021-06-09 | 17 | 0d |  |
| 19 | 4 | Celebracion de la reunion |  | 2d | 2021-06-17 | 2021-06-18 | 13FS+5d | 0d |  |
